Schedule from MS Project, 2004-03-01 to 2005-04-12, costs in $.

## Calendars

- Standard: Mon-Fri 08:00-12:00, 13:00-17:00; Sat-Sun off.

## Resources

| Resource | Rate |
| --- | --- |
| RDK | 150 |
| CEK | 120 |
| ARB | 80 |
| JTP | 80 |
| DLC | 100 |
| MLM | 120 |
| BRD | 86.17 |
| HLQ | 100 |

## Schedule

| ID | WBS | Task | Duration | Start | Finish | Predecessors | Baseline start | Baseline finish | Baseline duration | Total slack | Resources | Work | Cost | Baseline cost |
| --- | --- | --- | --- | --- | --- | --- | --- | --- | --- | --- | --- | --- | --- | --- |
| 1 | 1 | **Requirements Phase** | 65.5d | 2004-03-01 | 2004-05-31 |  | 2004-03-01 | 2004-05-31 | 65.5d | 0d | RDK | 1048h | 141,480 | 141,480 |
| 2 | 1.1 | Configuration Management Plan | 2d | 2004-03-01 | 2004-03-02 |  | 2004-03-01 | 2004-03-02 | 2d | 0d | CEK | 16h | 1,920 | 1,920 |
| 3 | 1.2 | Key users identified | 1d | 2004-03-03 | 2004-03-03 | 2 | 2004-03-03 | 2004-03-03 | 1d | 0d | CEK | 8h | 960 | 960 |
| 4 | 1.3 | User interviews | 7d | 2004-03-04 | 2004-03-12 | 3 | 2004-03-04 | 2004-03-12 | 7d | 0d | CEK | 56h | 6,720 | 6,720 |
| 5 | 1.4 | Use cases developed | 7d | 2004-03-15 | 2004-03-23 | 4 | 2004-03-15 | 2004-03-23 | 7d | 0d | CEK | 56h | 6,720 | 6,720 |
| 6 | 1.5 | User interface prototyped developed & approved | 14d | 2004-03-24 | 2004-04-12 | 5, 4 | 2004-03-24 | 2004-04-12 | 14d | 0d | CEK | 112h | 13,440 | 13,440 |
| 7 | 1.6 | Functional requirements writing | 20d | 2004-04-13 | 2004-05-10 | 6 | 2004-04-13 | 2004-05-10 | 20d | 0d | CEK | 160h | 19,200 | 19,200 |
| 8 | 1.7 | Project master test plan | 5d | 2004-05-11 | 2004-05-17 | 7 | 2004-05-11 | 2004-05-17 | 5d | 0d | CEK | 40h | 4,800 | 4,800 |
| 9 | 1.8 | Data Dictionary | 8d | 2004-05-18 | 2004-05-27 | 8 | 2004-05-18 | 2004-05-27 | 8d | 0d | CEK | 64h | 7,680 | 7,680 |
| 10 | 1.9 | Update Project Plan, refine estimates | 1.5d | 2004-05-28 | 2004-05-31 | 9 | 2004-05-28 | 2004-05-31 | 1.5d | 0d | CEK | 12h | 1,440 | 1,440 |
| 11 | 2 | **Functional Design Phase** | 32.5d | 2004-05-31 | 2004-07-14 | 10 | 2004-05-31 | 2004-07-14 | 32.5d | 0d | RDK | 520h | 70,200 | 70,200 |
| 12 | 2.1 | Logical Model | 4d | 2004-05-31 | 2004-06-04 | 10 | 2004-05-31 | 2004-06-04 | 4d | 0d | CEK | 32h | 3,840 | 3,840 |
| 13 | 2.2 | Data Dictionary (revised) | 2d | 2004-06-04 | 2004-06-08 | 12 | 2004-06-04 | 2004-06-08 | 2d | 0d | CEK | 16h | 1,920 | 1,920 |
| 14 | 2.3 | Requirements Traceability Matrix | 2d | 2004-06-08 | 2004-06-10 | 13 | 2004-06-08 | 2004-06-10 | 2d | 0d | CEK | 16h | 1,920 | 1,920 |
| 15 | 2.4 | Software Architecture | 5d | 2004-06-10 | 2004-06-17 | 14 | 2004-06-10 | 2004-06-17 | 5d | 0d | CEK | 40h | 4,800 | 4,800 |
| 16 | 2.5 | Functional Design Document | 18.5d | 2004-06-17 | 2004-07-13 | 15 | 2004-06-17 | 2004-07-13 | 18.5d | 0d | CEK | 148h | 17,760 | 17,760 |
| 17 | 2.6 | Update project plan, refine estimates | 1d | 2004-07-14 | 2004-07-14 | 16 | 2004-07-14 | 2004-07-14 | 1d | 0d | CEK | 8h | 960 | 960 |
| 18 | 3 | **System Design Phase** | 34d | 2004-07-15 | 2004-08-31 | 17 | 2004-07-15 | 2004-08-31 | 34d | 0d | RDK | 544h | 73,440 | 73,440 |
| 19 | 3.1 | Physical Model | 5d | 2004-07-15 | 2004-07-21 | 17 | 2004-07-15 | 2004-07-21 | 5d | 0d | CEK | 40h | 4,800 | 4,800 |
| 20 | 3.2 | Integration Test Plan (draft) | 2d | 2004-07-22 | 2004-07-23 | 19 | 2004-07-22 | 2004-07-23 | 2d | 0d | CEK | 16h | 1,920 | 1,920 |
| 21 | 3.3 | System Test Plan (draft) | 5d | 2004-07-26 | 2004-07-30 | 20 | 2004-07-26 | 2004-07-30 | 5d | 0d | CEK | 40h | 4,800 | 4,800 |
| 22 | 3.4 | Subsystem Specifications | 20d | 2004-08-02 | 2004-08-27 | 21 | 2004-08-02 | 2004-08-27 | 20d | 0d | CEK | 160h | 19,200 | 19,200 |
| 23 | 3.5 | Programming Standards | 1d | 2004-08-30 | 2004-08-30 | 22 | 2004-08-30 | 2004-08-30 | 1d | 0d | CEK | 8h | 960 | 960 |
| 24 | 3.6 | Update project plan, refine estimates | 1d | 2004-08-31 | 2004-08-31 | 23 | 2004-08-31 | 2004-08-31 | 1d | 0d | CEK | 8h | 960 | 960 |

| ID | WBS | Task | Type | Duration | Start | Finish | Predecessors | Baseline start | Baseline finish | Baseline duration | Total slack | Resources | Work | Cost | Baseline cost |
| --- | --- | --- | --- | --- | --- | --- | --- | --- | --- | --- | --- | --- | --- | --- | --- |
| 25 | 4 | **Programming Phase** |  | 108.5d | 2004-09-01 | 2005-01-31 | 24 | 2004-09-01 | 2005-01-31 | 108.5d | 0d |  | 2312h | 204,734.44 | 204,734.44 |
| 26 | 4.1 | Acceptance Test Plan (draft)( |  | 8d | 2004-09-01 | 2004-09-10 | 24 | 2004-09-01 | 2004-09-10 | 8d | 0d | BRD; HLQ | 128h | 11,914.88 | 11,914.88 |
| 27 | 4.2 | Integration Test Plan (final) |  | 8.5d | 2004-09-13 | 2004-09-23 | 26 | 2004-09-13 | 2004-09-23 | 8.5d | 0d | BRD; HLQ | 136h | 12,659.56 | 12,659.56 |
| 28 | 4.3 | System Test Plan (final) |  | 10d | 2004-09-23 | 2004-10-07 | 27 | 2004-09-23 | 2004-10-07 | 10d | 0d | MLM | 80h | 9,600 | 9,600 |
| 29 | 4.4 | **Subsystem X1** |  | 36d | 2004-10-07 | 2004-11-26 | 28 | 2004-10-07 | 2004-11-26 | 36d | 0d |  | 864h | 74,880 | 74,880 |
| 30 | 4.4.1 | code and document |  | 14.5d | 2004-10-07 | 2004-10-27 | 28 | 2004-10-07 | 2004-10-27 | 14.5d | 0d | ARB; JTP; DLC | 348h | 30,160 | 30,160 |
| 31 | 4.4.2 | test and debug |  | 21.5d | 2004-10-28 | 2004-11-26 | 30 | 2004-10-28 | 2004-11-26 | 21.5d | 0d | ARB; JTP; DLC | 516h | 44,720 | 44,720 |
| 32 | 4.5 | **Subsystem X2** |  | 21d | 2004-11-26 | 2004-12-27 | 31 | 2004-11-26 | 2004-12-27 | 21d | 0d |  | 504h | 43,680 | 43,680 |
| 33 | 4.5.1 | code and document |  | 8.5d | 2004-11-26 | 2004-12-08 | 31 | 2004-11-26 | 2004-12-08 | 8.5d | 0d | ARB; JTP; DLC | 204h | 17,680 | 17,680 |
| 34 | 4.5.2 | test and debug |  | 12.5d | 2004-12-09 | 2004-12-27 | 33 | 2004-12-09 | 2004-12-27 | 12.5d | 0d | ARB; JTP; DLC | 300h | 26,000 | 26,000 |
| 35 | 4.6 | **Subsystem X3** |  | 25d | 2004-12-27 | 2005-01-31 | 34 | 2004-12-27 | 2005-01-31 | 25d | 0d |  | 600h | 52,000 | 52,000 |
| 36 | 4.6.1 | code and document |  | 10d | 2004-12-27 | 2005-01-10 | 34 | 2004-12-27 | 2005-01-10 | 10d | 0d | ARB; JTP; DLC | 240h | 20,800 | 20,800 |
| 37 | 4.6.2 | test and debug |  | 15d | 2005-01-10 | 2005-01-31 | 36 | 2005-01-10 | 2005-01-31 | 15d | 0d | ARB; JTP; DLC | 360h | 31,200 | 31,200 |
| 38 | 5 | **System Integration and Testing Phase** |  | 44d | 2005-01-31 | 2005-04-01 | 37 | 2005-01-31 | 2005-04-01 | 44d | 0d |  | 608h | 59,179.52 | 59,179.52 |
| 39 | 5.1 | System integration and integration testing |  | 12d | 2005-01-31 | 2005-02-16 | 37 | 2005-01-31 | 2005-02-16 | 12d | 0d | MLM | 96h | 11,520 | 11,520 |
| 40 | 5.2 | System test execution and reporting |  | 30d | 2005-02-16 | 2005-03-30 | 39 | 2005-02-16 | 2005-03-30 | 30d | 0d | BRD; HLQ | 480h | 44,680.8 | 44,680.8 |
| 41 | 5.3 | Acceptance Test Plan (final) |  | 2d | 2005-03-30 | 2005-04-01 | 40 | 2005-03-30 | 2005-04-01 | 2d | 0d | BRD; HLQ | 32h | 2,978.72 | 2,978.72 |
| 42 | 6 | **Installation and Acceptance Phase** |  | 7d | 2005-04-01 | 2005-04-12 | 41 | 2005-04-01 | 2005-04-12 | 7d | 0d |  | 96h | 9,366.8 | 9,366.8 |
| 43 | 6.1 | System Installation |  | 2d | 2005-04-01 | 2005-04-05 | 41 | 2005-04-01 | 2005-04-05 | 2d | 0d | MLM | 16h | 1,920 | 1,920 |
| 44 | 6.2 | Acceptance Test |  | 5d | 2005-04-05 | 2005-04-12 | 43 | 2005-04-05 | 2005-04-12 | 5d | 0d | BRD; HLQ | 80h | 7,446.8 | 7,446.8 |
| 45 | 6.3 | Operational System | milestone | 0d | 2005-04-12 | 2005-04-12 | 44 | 2005-04-12 | 2005-04-12 | 0d | 0d | BRD; HLQ |  |  |  |
